# Business Process Phase Gantt Chart

Schedule from MS Project, 2009-02-01 to 2009-05-29.
Project Perfect

## Calendars

- Standard: Mon-Fri 08:00-12:00, 13:00-17:00; Sat-Sun off.

## Schedule

| ID | WBS | Task | Type | Duration | Start | Finish | Predecessors | Total slack |
| --- | --- | --- | --- | --- | --- | --- | --- | --- |
| 1 | 1 | NOTE: All time estimates are duration rather than work. They will have to be scaled up or down to suit the project. | milestone | 0d | 2009-02-01 | 2009-02-01 |  | 20.6d |
| 4 | 2 | **Phase Planning** |  | 2.3d | 2009-02-02 | 2009-02-04 |  | 0d |
| 5 | 2.1 | Review the draft plan and look for changes |  | 0.2d | 2009-02-02 | 2009-02-02 |  | 0d |
| 6 | 2.2 | Prepare a schedule (Gantt Chart) |  | 0.2d | 2009-02-02 | 2009-02-02 | 5 | 0d |
| 7 | 2.3 | Allocate resources |  | 0.2d | 2009-02-02 | 2009-02-02 | 6 | 0d |
| 8 | 2.4 | Confirm resource availability |  | 0.5d | 2009-02-02 | 2009-02-03 | 7 | 0d |
| 9 | 2.5 | Revise list of issues and risks |  | 0.2d | 2009-02-03 | 2009-02-03 | 8 | 0d |
| 10 | 2.6 | Gain agreement to proceed |  | 1d | 2009-02-03 | 2009-02-04 | 9 | 0d |
| 11 | 2.7 | Planning complete | milestone | 0d | 2009-02-04 | 2009-02-04 | 10 | 0d |
| 12 | 3 | **Kick Off Meeting** |  | 2.5d | 2009-02-02 | 2009-02-04 |  | 0d |
| 13 | 3.1 | Schedule meeting |  | 2d | 2009-02-02 | 2009-02-03 |  | 0.3d |
| 14 | 3.2 | Prepare material |  | 1d | 2009-02-02 | 2009-02-02 |  | 1d |
| 15 | 3.3 | Hold meeting |  | 0.2d | 2009-02-04 | 2009-02-04 | 13, 14, 11 | 0d |
| 16 | 3.4 | Kick Off meeting complete | milestone | 0d | 2009-02-04 | 2009-02-04 | 15 | 0d |
| 17 | 4 | **Existing Processes** |  | 28d | 2009-02-04 | 2009-03-16 | 16 | 0d |
| 18 | 4.1 | Determine processes to be mapped |  | 3d | 2009-02-04 | 2009-02-09 |  | 0d |
| 19 | 4.2 | Map existing processes |  | 20d | 2009-02-09 | 2009-03-09 | 18 | 0d |
| 20 | 4.3 | Identify process impacts |  | 5d | 2009-03-09 | 2009-03-16 | 19 | 0d |
| 21 | 4.4 | Existing processes mapped | milestone | 0d | 2009-03-16 | 2009-03-16 | 20 | 0d |
| 22 | 5 | **New Processes** |  | 36d | 2009-03-16 | 2009-05-05 | 21 | 0d |
| 23 | 5.1 | Design new processes |  | 30d | 2009-03-16 | 2009-04-27 |  | 0d |
| 24 | 5.2 | Validate new processes |  | 5d | 2009-04-27 | 2009-05-04 | 23 | 0d |
| 25 | 5.3 | Split into pre and post processes |  | 1d | 2009-05-04 | 2009-05-05 | 24 | 0d |
| 26 | 5.4 | New processes mapped | milestone | 0d | 2009-05-05 | 2009-05-05 | 25 | 0d |

| ID | WBS | Task | Type | Duration | Start | Finish | Predecessors | Total slack | Free slack |
| --- | --- | --- | --- | --- | --- | --- | --- | --- | --- |
| 27 | 6 | **Pre Process Training** |  | 12d | 2009-05-05 | 2009-05-21 | 26 | 0d |  |
| 28 | 6.1 | Prepare materials |  | 5d | 2009-05-05 | 2009-05-12 |  | 2d | 0d |
| 29 | 6.2 | Schedule training |  | 5d | 2009-05-05 | 2009-05-12 |  | 0d |  |
| 30 | 6.3 | Carry out training |  | 2d | 2009-05-12 | 2009-05-14 | 29 | 0d |  |
| 31 | 6.4 | Implement new processes |  | 5d | 2009-05-14 | 2009-05-21 | 30 | 0d |  |
| 32 | 6.5 | New Pre Processes in place | milestone | 0d | 2009-05-21 | 2009-05-21 | 31 | 0d |  |
| 33 | 7 | **Post Process Training** |  | 5d | 2009-05-12 | 2009-05-19 | 28 | 2d |  |
| 34 | 7.1 | Prepare materials |  | 5d | 2009-05-12 | 2009-05-19 |  | 2d | 0d |
| 35 | 7.2 | Post Training complete | milestone | 0d | 2009-05-19 | 2009-05-19 | 34 | 2d |  |
| 36 | 8 | **Report** |  | 4d | 2009-05-21 | 2009-05-27 | 35, 32 | 0d |  |
| 37 | 8.1 | Produce report |  | 2d | 2009-05-21 | 2009-05-25 |  | 0d |  |
| 38 | 8.2 | Carry out QA |  | 0.5d | 2009-05-25 | 2009-05-25 | 37 | 0d |  |
| 39 | 8.3 | Carry out rework |  | 1d | 2009-05-26 | 2009-05-26 | 38 | 0d |  |
| 40 | 8.4 | Present report |  | 0.5d | 2009-05-27 | 2009-05-27 | 39 | 0d |  |
| 41 | 8.5 | Report complete | milestone | 0d | 2009-05-27 | 2009-05-27 | 40 | 0d |  |
| 42 | 9 | **Closure** |  | 1.9d | 2009-05-27 | 2009-05-29 | 41 | 0d |  |
| 43 | 9.1 | Produce plan for next phase |  | 0.4d | 2009-05-27 | 2009-05-27 |  | 0d |  |
| 44 | 9.2 | Agree plan with the Sponsor |  | 1d | 2009-05-27 | 2009-05-28 | 43 | 0d |  |
| 45 | 9.3 | Agree to proceed through the gate to the next phase |  | 0.5d | 2009-05-28 | 2009-05-29 | 44 | 0d |  |
| 46 | 9.4 | Phase complete | milestone | 0d | 2009-05-29 | 2009-05-29 | 45 | 0d |  |
